Schedule from MS Project, 2024-07-30 to 2025-02-27, status date 2021-11-15.

## Calendars

- Standard: Mon-Tue 08:00-13:30, 14:30-17:00; Wed 08:00-13:30, 14:30-20:00; Thu 08:00-13:30, 14:30-17:00; Fri off; Sat 08:00-13:30, 14:30-20:00; Sun 08:00-13:30, 14:30-17:00.

## Schedule

| ID | WBS | Task | Duration | Start | Finish | Predecessors | Total slack | Free slack | پایان | شروع |
| --- | --- | --- | --- | --- | --- | --- | --- | --- | --- | --- |
| 1 | 1 | **Shell & Tube Heat exchanger** | 205d | 2024-07-30 | 2025-02-27 |  | 0d |  | 1403/12/9 | 1403/5/9 |
| 2 | 1.1 | **Engineering** | 169d | 2024-07-30 | 2025-01-21 |  | 0d |  | 1403/11/2 | 1403/5/9 |
| 3 | 1.1.1 | Vendor Print Index & Schedule (VPIS) | 1d | 2024-07-30 | 2024-07-30 |  | 0d |  | 1403/5/9 | 1403/5/9 |
| 4 | 1.1.2 | Sub-Vendor List (SVL) | 5d | 2024-07-31 | 2024-08-05 | 3 | 33d | 0d | 1403/5/15 | 1403/5/10 |
| 5 | 1.1.3 | Final vendor Data Book Index | 3d | 2025-01-07 | 2025-01-11 | 4FS+150d | 33d | 0d | 1403/10/22 | 1403/10/18 |
| 6 | 1.1.4 | Final vendor Data Book | 10d | 2025-01-11 | 2025-01-21 | 5 | 33d | 29d | 1403/11/2 | 1403/10/22 |
| 7 | 1.1.5 | HSE Plan | 6d | 2024-07-31 | 2024-08-06 | 3 | 198d |  | 1403/5/16 | 1403/5/10 |
| 8 | 1.1.6 | WBS for Shell & Tube Heat Exchangers | 7d | 2024-07-31 | 2024-08-07 | 3 | 180d | 0d | 1403/5/17 | 1403/5/10 |
| 9 | 1.1.7 | Time Schedule for Shell & Tube Heat Exchangers | 7d | 2024-08-07 | 2024-08-14 | 8 | 180d | 0d | 1403/5/24 | 1403/5/17 |
| 10 | 1.1.8 | Monthly Progress Report for Shell & Tube Heat Exchangers | 7d | 2024-08-14 | 2024-08-21 | 9 | 180d | 176d | 1403/5/31 | 1403/5/24 |
| 11 | 1.1.9 | As Built Drawing | 15d | 2024-07-31 | 2024-08-15 | 3 | 0d |  | 1403/5/25 | 1403/5/10 |
| 12 | 1.1.10 | Inspection & Test Plan (ITP) | 6d | 2024-08-15 | 2024-08-21 | 11 | 85d | 0d | 1403/5/31 | 1403/5/25 |
| 13 | 1.1.11 | Welding Document (WPS & PQR) | 10d | 2024-08-21 | 2024-09-01 | 12 | 85d | 0d | 1403/6/11 | 1403/5/31 |
| 14 | 1.1.12 | Welding & NDT Map | 7d | 2024-09-01 | 2024-09-08 | 13 | 85d | 0d | 1403/6/18 | 1403/6/11 |
| 15 | 1.1.13 | NDT Operator Qualification | 7d | 2024-09-08 | 2024-09-15 | 14 | 85d | 0d | 1403/6/25 | 1403/6/18 |
| 16 | 1.1.14 | Welder Performance Qualification | 5d | 2024-09-15 | 2024-09-21 | 15 | 85d | 0d | 1403/6/31 | 1403/6/25 |
| 17 | 1.1.15 | NDT Procedure (RT, UT, PT, MT) | 7d | 2024-09-21 | 2024-09-28 | 16 | 85d | 0d | 1403/7/7 | 1403/6/31 |
| 18 | 1.1.16 | Hydrostatic Test Procedure | 7d | 2024-09-28 | 2024-10-05 | 17 | 85d | 0d | 1403/7/14 | 1403/7/7 |
| 19 | 1.1.17 | Surface Preparation & Painting Procedure | 7d | 2024-10-05 | 2024-10-12 | 18 | 85d | 54d | 1403/7/21 | 1403/7/14 |
| 20 | 1.2 | **Procurement** | 170d | 2024-07-31 | 2025-01-22 |  | 0d |  | 1403/11/3 | 1403/5/10 |
| 21 | 1.2.1 | **Plate** | 125d | 2024-07-31 | 2024-12-07 |  | 2d |  | 1403/9/17 | 1403/5/10 |
| 22 | 1.2.1.1 | PO placement | 10d | 2024-07-31 | 2024-08-10 | 11SS | 2d | 0d | 1403/5/20 | 1403/5/10 |
| 23 | 1.2.1.2 | Fabrication | 90d | 2024-08-10 | 2024-11-11 | 22 | 2d | 0d | 1403/8/21 | 1403/5/20 |
| 24 | 1.2.1.3 | Shipping | 20d | 2024-11-11 | 2024-12-02 | 23 | 2d | 0d | 1403/9/12 | 1403/8/21 |
| 25 | 1.2.1.4 | Custom clearance | 5d | 2024-12-02 | 2024-12-07 | 24 | 2d | 0d | 1403/9/17 | 1403/9/12 |

| ID | WBS | Task | Duration | Start | Finish | Predecessors | Total slack | Free slack | پایان | شروع |
| --- | --- | --- | --- | --- | --- | --- | --- | --- | --- | --- |
| 26 | 1.2.2 | **Head** | 125d | 2024-07-31 | 2024-12-07 |  | 43d |  | 1403/9/17 | 1403/5/10 |
| 27 | 1.2.2.1 | PO placement | 10d | 2024-07-31 | 2024-08-10 | 11SS | 43d | 0d | 1403/5/20 | 1403/5/10 |
| 28 | 1.2.2.2 | Fabrication | 90d | 2024-08-10 | 2024-11-11 | 27 | 43d | 0d | 1403/8/21 | 1403/5/20 |
| 29 | 1.2.2.3 | Shipping | 20d | 2024-11-11 | 2024-12-02 | 28 | 43d | 0d | 1403/9/12 | 1403/8/21 |
| 30 | 1.2.2.4 | Custom clearance | 5d | 2024-12-02 | 2024-12-07 | 29 | 43d | 39d | 1403/9/17 | 1403/9/12 |
| 31 | 1.2.3 | **U-Tube** | 125d | 2024-07-31 | 2024-12-07 |  | 40d |  | 1403/9/17 | 1403/5/10 |
| 32 | 1.2.3.1 | PO placement | 10d | 2024-07-31 | 2024-08-10 | 11SS | 40d | 0d | 1403/5/20 | 1403/5/10 |
| 33 | 1.2.3.2 | Fabrication | 90d | 2024-08-10 | 2024-11-11 | 32 | 40d | 0d | 1403/8/21 | 1403/5/20 |
| 34 | 1.2.3.3 | Shipping | 20d | 2024-11-11 | 2024-12-02 | 33 | 40d | 0d | 1403/9/12 | 1403/8/21 |
| 35 | 1.2.3.4 | Custom clearance | 5d | 2024-12-02 | 2024-12-07 | 34 | 40d | 32d | 1403/9/17 | 1403/9/12 |
| 36 | 1.2.4 | **Tube sheet** | 145d | 2024-07-31 | 2024-12-28 |  | 15d |  | 1403/10/8 | 1403/5/10 |
| 37 | 1.2.4.1 | PO placement | 10d | 2024-07-31 | 2024-08-10 | 11SS | 15d | 0d | 1403/5/20 | 1403/5/10 |
| 38 | 1.2.4.2 | Fabrication | 110d | 2024-08-10 | 2024-12-02 | 37 | 15d | 0d | 1403/9/12 | 1403/5/20 |
| 39 | 1.2.4.3 | Shipping | 20d | 2024-12-02 | 2024-12-23 | 38 | 15d | 0d | 1403/10/3 | 1403/9/12 |
| 40 | 1.2.4.4 | Custom clearance | 5d | 2024-12-23 | 2024-12-28 | 39 | 15d | 7d | 1403/10/8 | 1403/10/3 |
| 41 | 1.2.5 | **Baffle** | 145d | 2024-07-31 | 2024-12-28 |  | 15d |  | 1403/10/8 | 1403/5/10 |
| 42 | 1.2.5.1 | PO placement | 10d | 2024-07-31 | 2024-08-10 | 11SS | 15d | 0d | 1403/5/20 | 1403/5/10 |
| 43 | 1.2.5.2 | Fabrication | 110d | 2024-08-10 | 2024-12-02 | 42 | 15d | 0d | 1403/9/12 | 1403/5/20 |
| 44 | 1.2.5.3 | Shipping | 20d | 2024-12-02 | 2024-12-23 | 43 | 15d | 0d | 1403/10/3 | 1403/9/12 |
| 45 | 1.2.5.4 | Custom clearance | 5d | 2024-12-23 | 2024-12-28 | 44 | 15d | 7d | 1403/10/8 | 1403/10/3 |
| 46 | 1.2.6 | **Elbow** | 125d | 2024-07-31 | 2024-12-07 |  | 79d |  | 1403/9/17 | 1403/5/10 |
| 47 | 1.2.6.1 | PO placement | 10d | 2024-07-31 | 2024-08-10 | 11SS | 79d | 0d | 1403/5/20 | 1403/5/10 |
| 48 | 1.2.6.2 | Fabrication | 90d | 2024-08-10 | 2024-11-11 | 47 | 79d | 0d | 1403/8/21 | 1403/5/20 |
| 49 | 1.2.6.3 | Shipping | 20d | 2024-11-11 | 2024-12-02 | 48 | 79d | 0d | 1403/9/12 | 1403/8/21 |
| 50 | 1.2.6.4 | Custom clearance | 5d | 2024-12-02 | 2024-12-07 | 49 | 79d |  | 1403/9/17 | 1403/9/12 |

| ID | WBS | Task | Duration | Start | Finish | Predecessors | Total slack | Free slack | پایان | شروع |
| --- | --- | --- | --- | --- | --- | --- | --- | --- | --- | --- |
| 51 | 1.2.7 | **Pipe** | 125d | 2024-07-31 | 2024-12-07 |  | 4d |  | 1403/9/17 | 1403/5/10 |
| 52 | 1.2.7.1 | PO placement | 10d | 2024-07-31 | 2024-08-10 | 11SS | 4d | 0d | 1403/5/20 | 1403/5/10 |
| 53 | 1.2.7.2 | Fabrication | 90d | 2024-08-10 | 2024-11-11 | 52 | 4d | 0d | 1403/8/21 | 1403/5/20 |
| 54 | 1.2.7.3 | Shipping | 20d | 2024-11-11 | 2024-12-02 | 53 | 4d | 0d | 1403/9/12 | 1403/8/21 |
| 55 | 1.2.7.4 | Custom clearance | 5d | 2024-12-02 | 2024-12-07 | 54 | 4d | 0d | 1403/9/17 | 1403/9/12 |
| 56 | 1.2.8 | **Flange** | 125d | 2024-07-31 | 2024-12-07 |  | 22d |  | 1403/9/17 | 1403/5/10 |
| 57 | 1.2.8.1 | PO placement | 10d | 2024-07-31 | 2024-08-10 | 11SS | 22d | 0d | 1403/5/20 | 1403/5/10 |
| 58 | 1.2.8.2 | Fabrication | 90d | 2024-08-10 | 2024-11-11 | 57 | 22d | 0d | 1403/8/21 | 1403/5/20 |
| 59 | 1.2.8.3 | Shipping | 20d | 2024-11-11 | 2024-12-02 | 58 | 22d | 0d | 1403/9/12 | 1403/8/21 |
| 60 | 1.2.8.4 | Custom clearance | 5d | 2024-12-02 | 2024-12-07 | 59 | 22d | 9d | 1403/9/17 | 1403/9/12 |
| 61 | 1.2.9 | **Spacer** | 145d | 2024-07-31 | 2024-12-28 |  | 0d |  | 1403/10/8 | 1403/5/10 |
| 62 | 1.2.9.1 | PO placement | 10d | 2024-07-31 | 2024-08-10 | 11SS | 0d |  | 1403/5/20 | 1403/5/10 |
| 63 | 1.2.9.2 | Fabrication | 110d | 2024-08-10 | 2024-12-02 | 62 | 0d |  | 1403/9/12 | 1403/5/20 |
| 64 | 1.2.9.3 | Shipping | 20d | 2024-12-02 | 2024-12-23 | 63 | 0d |  | 1403/10/3 | 1403/9/12 |
| 65 | 1.2.9.4 | Custom clearance | 5d | 2024-12-23 | 2024-12-28 | 64 | 0d |  | 1403/10/8 | 1403/10/3 |
| 66 | 1.2.10 | **Nut & bolt** | 145d | 2024-07-31 | 2024-12-28 |  | 53d |  | 1403/10/8 | 1403/5/10 |
| 67 | 1.2.10.1 | PO placement | 10d | 2024-07-31 | 2024-08-10 | 11SS | 53d | 0d | 1403/5/20 | 1403/5/10 |
| 68 | 1.2.10.2 | Fabrication | 110d | 2024-08-10 | 2024-12-02 | 67 | 53d | 0d | 1403/9/12 | 1403/5/20 |
| 69 | 1.2.10.3 | Shipping | 20d | 2024-12-02 | 2024-12-23 | 68 | 53d | 0d | 1403/10/3 | 1403/9/12 |
| 70 | 1.2.10.4 | Custom clearance | 5d | 2024-12-23 | 2024-12-28 | 69 | 53d | 49d | 1403/10/8 | 1403/10/3 |
| 71 | 1.2.11 | **Gasket** | 145d | 2024-07-31 | 2024-12-28 |  | 53d |  | 1403/10/8 | 1403/5/10 |
| 72 | 1.2.11.1 | PO placement | 10d | 2024-07-31 | 2024-08-10 | 11SS | 53d | 0d | 1403/5/20 | 1403/5/10 |
| 73 | 1.2.11.2 | Fabrication | 110d | 2024-08-10 | 2024-12-02 | 72 | 53d | 0d | 1403/9/12 | 1403/5/20 |
| 74 | 1.2.11.3 | Shipping | 20d | 2024-12-02 | 2024-12-23 | 73 | 53d | 0d | 1403/10/3 | 1403/9/12 |
| 75 | 1.2.11.4 | Custom clearance | 5d | 2024-12-23 | 2024-12-28 | 74 | 53d | 49d | 1403/10/8 | 1403/10/3 |

| ID | WBS | Task | Duration | Start | Finish | Predecessors | Total slack | Free slack | پایان | شروع |
| --- | --- | --- | --- | --- | --- | --- | --- | --- | --- | --- |
| 76 | 1.2.12 | **Paint** | 45d | 2024-12-07 | 2025-01-22 |  | 31d |  | 1403/11/3 | 1403/9/17 |
| 77 | 1.2.12.1 | PO placement | 10d | 2024-12-07 | 2024-12-17 | 11FS+110d, 19 | 31d | 0d | 1403/9/27 | 1403/9/17 |
| 78 | 1.2.12.2 | Fabrication | 30d | 2024-12-18 | 2025-01-18 | 77 | 31d | 0d | 1403/10/29 | 1403/9/28 |
| 79 | 1.2.12.3 | Shipping | 5d | 2025-01-18 | 2025-01-22 | 78 | 31d | 27d | 1403/11/3 | 1403/10/29 |
| 80 | 1.2.13 | **Name plate** | 45d | 2024-12-07 | 2025-01-22 |  | 31d |  | 1403/11/3 | 1403/9/17 |
| 81 | 1.2.13.1 | PO placement | 10d | 2024-12-07 | 2024-12-17 | 11FS+110d | 31d | 0d | 1403/9/27 | 1403/9/17 |
| 82 | 1.2.13.2 | Fabrication | 30d | 2024-12-18 | 2025-01-18 | 81 | 31d | 0d | 1403/10/29 | 1403/9/28 |
| 83 | 1.2.13.3 | Shipping | 5d | 2025-01-18 | 2025-01-22 | 82 | 31d | 27d | 1403/11/3 | 1403/10/29 |
| 84 | 1.3 | **Fabrication** | 79d | 2024-12-07 | 2025-02-27 |  | 0d |  | 1403/12/9 | 1403/9/17 |
| 85 | 1.3.1 | **RU-0001A-E-02** | 75d | 2024-12-07 | 2025-02-23 |  | 4d |  | 1403/12/5 | 1403/9/17 |
| 86 | 1.3.1.1 | **Prefabrication** | 31d | 2024-12-07 | 2025-01-08 |  | 5d |  | 1403/10/19 | 1403/9/17 |
| 87 | 1.3.1.1.1 | **Shell** | 21d | 2024-12-07 | 2024-12-29 |  | 5d |  | 1403/10/9 | 1403/9/17 |
| 88 | 1.3.1.1.1.1 | Cutting | 2d | 2024-12-07 | 2024-12-09 | 25 | 5d | 0d | 1403/9/19 | 1403/9/17 |
| 89 | 1.3.1.1.1.2 | Beveling | 2d | 2024-12-09 | 2024-12-11 | 88 | 5d | 0d | 1403/9/21 | 1403/9/19 |
| 90 | 1.3.1.1.1.3 | Rolling | 2d | 2024-12-11 | 2024-12-14 | 89 | 5d | 0d | 1403/9/24 | 1403/9/21 |
| 91 | 1.3.1.1.1.4 | Assembly (LW) | 5d | 2024-12-14 | 2024-12-18 | 90 | 5d | 0d | 1403/9/28 | 1403/9/24 |
| 92 | 1.3.1.1.1.5 | Welding (LW) | 9d | 2024-12-18 | 2024-12-28 | 91 | 5d | 0d | 1403/10/8 | 1403/9/28 |
| 93 | 1.3.1.1.1.6 | Reroll | 1d | 2024-12-28 | 2024-12-29 | 92 | 5d | 0d | 1403/10/9 | 1403/10/8 |
| 94 | 1.3.1.1.2 | **Channel** | 15d | 2024-12-07 | 2024-12-23 |  | 17d |  | 1403/10/3 | 1403/9/17 |
| 95 | 1.3.1.1.2.1 | Cutting | 2d | 2024-12-07 | 2024-12-09 | 25 | 17d | 0d | 1403/9/19 | 1403/9/17 |
| 96 | 1.3.1.1.2.2 | Beveling | 2d | 2024-12-09 | 2024-12-11 | 95 | 17d | 0d | 1403/9/21 | 1403/9/19 |
| 97 | 1.3.1.1.2.3 | Rolling | 2d | 2024-12-11 | 2024-12-14 | 96 | 17d | 0d | 1403/9/24 | 1403/9/21 |
| 98 | 1.3.1.1.2.4 | Assembly (LW) | 3d | 2024-12-14 | 2024-12-16 | 97 | 17d | 0d | 1403/9/26 | 1403/9/24 |
| 99 | 1.3.1.1.2.5 | Welding (LW) | 5d | 2024-12-17 | 2024-12-22 | 98 | 17d | 0d | 1403/10/2 | 1403/9/27 |
| 100 | 1.3.1.1.2.6 | Reroll | 1d | 2024-12-22 | 2024-12-23 | 99 | 17d | 0d | 1403/10/3 | 1403/10/2 |

| ID | WBS | Task | Duration | Start | Finish | Predecessors | Total slack | Free slack | پایان | شروع |
| --- | --- | --- | --- | --- | --- | --- | --- | --- | --- | --- |
| 101 | 1.3.1.1.3 | **Cone** | 15d | 2024-12-17 | 2025-01-01 |  | 24d |  | 1403/10/12 | 1403/9/27 |
| 102 | 1.3.1.1.3.1 | Cutting | 2d | 2024-12-17 | 2024-12-18 | 25FS+9d | 24d | 0d | 1403/9/28 | 1403/9/27 |
| 103 | 1.3.1.1.3.2 | Beveling | 2d | 2024-12-18 | 2024-12-21 | 102 | 24d | 0d | 1403/10/1 | 1403/9/28 |
| 104 | 1.3.1.1.3.3 | Rolling | 2d | 2024-12-21 | 2024-12-23 | 103 | 24d | 0d | 1403/10/3 | 1403/10/1 |
| 105 | 1.3.1.1.3.4 | Assembly (LW) | 3d | 2024-12-23 | 2024-12-25 | 104 | 24d | 0d | 1403/10/5 | 1403/10/3 |
| 106 | 1.3.1.1.3.5 | Welding (LW) | 5d | 2024-12-25 | 2024-12-31 | 105 | 24d | 0d | 1403/10/11 | 1403/10/5 |
| 107 | 1.3.1.1.3.6 | Reroll | 1d | 2024-12-31 | 2025-01-01 | 106 | 24d | 20d | 1403/10/12 | 1403/10/11 |
| 108 | 1.3.1.1.4 | **Saddle fabrication** | 15d | 2024-12-23 | 2025-01-07 |  | 35d |  | 1403/10/18 | 1403/10/3 |
| 109 | 1.3.1.1.4.1 | Cutting | 2d | 2024-12-23 | 2024-12-25 | 25FS+15d | 35d | 0d | 1403/10/5 | 1403/10/3 |
| 110 | 1.3.1.1.4.2 | Beveling | 2d | 2024-12-25 | 2024-12-26 | 109 | 35d | 0d | 1403/10/6 | 1403/10/5 |
| 111 | 1.3.1.1.4.3 | Rolling | 2d | 2024-12-26 | 2024-12-29 | 110 | 35d | 0d | 1403/10/9 | 1403/10/6 |
| 112 | 1.3.1.1.4.4 | Assembly (LW) | 3d | 2024-12-29 | 2025-01-01 | 111 | 35d | 0d | 1403/10/12 | 1403/10/9 |
| 113 | 1.3.1.1.4.5 | Welding (LW) | 5d | 2025-01-01 | 2025-01-06 | 112 | 35d | 0d | 1403/10/17 | 1403/10/12 |
| 114 | 1.3.1.1.4.6 | Reroll | 1d | 2025-01-06 | 2025-01-07 | 113 | 35d | 31d | 1403/10/18 | 1403/10/17 |
| 115 | 1.3.1.1.5 | **Nozzle fabrication (part 1)** | 12d | 2024-12-18 | 2024-12-30 |  | 13d |  | 1403/10/10 | 1403/9/28 |
| 116 | 1.3.1.1.5.1 | Pipe cutting | 2d | 2024-12-18 | 2024-12-19 | 55FS+10d | 13d | 0d | 1403/9/29 | 1403/9/28 |
| 117 | 1.3.1.1.5.2 | Pipe beveling | 2d | 2024-12-19 | 2024-12-22 | 116 | 13d | 0d | 1403/10/2 | 1403/9/29 |
| 118 | 1.3.1.1.5.3 | Assembly pipe to flange | 3d | 2024-12-22 | 2024-12-25 | 60FS+5d, 117 | 13d | 0d | 1403/10/5 | 1403/10/2 |
| 119 | 1.3.1.1.5.4 | Welding pipe to flange | 5d | 2024-12-25 | 2024-12-30 | 118 | 13d | 9d | 1403/10/10 | 1403/10/5 |
| 120 | 1.3.1.1.6 | **Nozzle fabrication (part 2)** | 26d | 2024-12-12 | 2025-01-08 |  | 4d |  | 1403/10/19 | 1403/9/22 |
| 121 | 1.3.1.1.6.1 | Pipe cutting | 3d | 2024-12-12 | 2024-12-15 | 55FS+5d | 4d | 0d | 1403/9/25 | 1403/9/22 |
| 122 | 1.3.1.1.6.2 | Pipe beveling | 3d | 2024-12-16 | 2024-12-18 | 121 | 4d | 0d | 1403/9/28 | 1403/9/26 |
| 123 | 1.3.1.1.6.3 | Assembly pipe to flange | 5d | 2024-12-18 | 2024-12-24 | 122 | 4d | 0d | 1403/10/4 | 1403/9/28 |
| 124 | 1.3.1.1.6.4 | Welding pipe to flange | 7d | 2024-12-24 | 2024-12-31 | 123 | 4d | 0d | 1403/10/11 | 1403/10/4 |
| 125 | 1.3.1.1.6.5 | Assembly elbow to pipe | 3d | 2024-12-31 | 2025-01-04 | 124 | 4d | 0d | 1403/10/15 | 1403/10/11 |
| 126 | 1.3.1.1.6.6 | Welding elbow to pipe | 5d | 2025-01-04 | 2025-01-08 | 125 | 4d | 0d | 1403/10/19 | 1403/10/15 |

| ID | WBS | Task | Duration | Start | Finish | Predecessors | Total slack | Free slack | پایان | شروع |
| --- | --- | --- | --- | --- | --- | --- | --- | --- | --- | --- |
| 127 | 1.3.1.2 | **Final assembly** | 48d | 2024-12-29 | 2025-02-17 |  | 4d |  | 1403/11/29 | 1403/10/9 |
| 128 | 1.3.1.2.1 | **Shell** | 35d | 2024-12-29 | 2025-02-03 |  | 4d |  | 1403/11/15 | 1403/10/9 |
| 129 | 1.3.1.2.1.1 | Assembly shell segments (CW) | 3d | 2024-12-29 | 2025-01-01 | 93 | 5d | 0d | 1403/10/12 | 1403/10/9 |
| 130 | 1.3.1.2.1.2 | Welding shell segments (CW) | 5d | 2025-01-01 | 2025-01-06 | 129 | 5d | 0d | 1403/10/17 | 1403/10/12 |
| 131 | 1.3.1.2.1.3 | Opening for nozzle assembly | 1d | 2025-01-06 | 2025-01-07 | 130 | 5d | 1d | 1403/10/18 | 1403/10/17 |
| 132 | 1.3.1.2.1.4 | Nozzle assembly to shell | 3d | 2025-01-08 | 2025-01-11 | 131, 119, 126 | 4d | 0d | 1403/10/22 | 1403/10/19 |
| 133 | 1.3.1.2.1.5 | Nozzle welding to shell | 5d | 2025-01-12 | 2025-01-16 | 132 | 4d | 0d | 1403/10/27 | 1403/10/23 |
| 134 | 1.3.1.2.1.6 | Assembly head to shell | 2d | 2025-01-16 | 2025-01-19 | 133, 30 | 4d | 0d | 1403/10/30 | 1403/10/27 |
| 135 | 1.3.1.2.1.7 | Welding head to shell | 3d | 2025-01-19 | 2025-01-22 | 134 | 4d | 0d | 1403/11/3 | 1403/10/30 |
| 136 | 1.3.1.2.1.8 | Assembly cone to shell | 1d | 2025-01-22 | 2025-01-22 | 135, 107 | 4d | 0d | 1403/11/3 | 1403/11/3 |
| 137 | 1.3.1.2.1.9 | Welding cone to shell | 3d | 2025-01-22 | 2025-01-26 | 136 | 4d | 0d | 1403/11/7 | 1403/11/3 |
| 138 | 1.3.1.2.1.10 | Assembly segment shell to cone | 1d | 2025-01-26 | 2025-01-27 | 137 | 4d | 0d | 1403/11/8 | 1403/11/7 |
| 139 | 1.3.1.2.1.11 | Welding segment shell to cone | 3d | 2025-01-27 | 2025-01-30 | 138 | 4d | 0d | 1403/11/11 | 1403/11/8 |
| 140 | 1.3.1.2.1.12 | Assembly body flange to shell | 1d | 2025-01-30 | 2025-02-01 | 139 | 4d | 0d | 1403/11/13 | 1403/11/11 |
| 141 | 1.3.1.2.1.13 | Welding body flange to shell | 3d | 2025-02-01 | 2025-02-03 | 140 | 4d | 0d | 1403/11/15 | 1403/11/13 |
| 142 | 1.3.1.2.2 | **Channel** | 19d | 2025-01-18 | 2025-02-06 |  | 14d |  | 1403/11/18 | 1403/10/29 |
| 143 | 1.3.1.2.2.1 | Assembly head to channel | 2d | 2025-01-18 | 2025-01-20 | 100FS+25d | 17d | 0d | 1403/11/1 | 1403/10/29 |
| 144 | 1.3.1.2.2.2 | Welding head to channel | 3d | 2025-01-20 | 2025-01-22 | 143 | 17d | 0d | 1403/11/3 | 1403/11/1 |
| 145 | 1.3.1.2.2.3 | Assembly body flange to channel | 2d | 2025-01-22 | 2025-01-25 | 144 | 17d | 0d | 1403/11/6 | 1403/11/3 |
| 146 | 1.3.1.2.2.4 | Welding body flange to channel | 3d | 2025-01-25 | 2025-01-28 | 145 | 17d | 0d | 1403/11/9 | 1403/11/6 |
| 147 | 1.3.1.2.2.5 | Opening for nozzle assembly | 1d | 2025-01-28 | 2025-01-29 | 146 | 17d | 0d | 1403/11/10 | 1403/11/9 |
| 148 | 1.3.1.2.2.6 | Assembly nozzle to channel | 2d | 2025-01-29 | 2025-02-01 | 147 | 17d | 3d | 1403/11/13 | 1403/11/10 |
| 149 | 1.3.1.2.2.7 | Welding nozzle to channel | 3d | 2025-02-03 | 2025-02-06 | 148, 141 | 14d | 10d | 1403/11/18 | 1403/11/15 |
| 150 | 1.3.1.2.3 | **Bundle structure** | 42d | 2025-01-04 | 2025-02-17 |  | 4d |  | 1403/11/29 | 1403/10/15 |
| 151 | 1.3.1.2.3.1 | Assembly bundle structure | 5d | 2025-01-04 | 2025-01-09 | 40, 45, 65FS+7d | 8d | 0d | 1403/10/20 | 1403/10/15 |
| 152 | 1.3.1.2.3.2 | Insert tube to bundle structure | 2d | 2025-01-09 | 2025-01-11 | 151, 35 | 8d | 0d | 1403/10/22 | 1403/10/20 |
| 153 | 1.3.1.2.3.3 | Tube to tube sheet welding | 15d | 2025-01-12 | 2025-01-27 | 152 | 8d | 0d | 1403/11/8 | 1403/10/23 |
| 154 | 1.3.1.2.3.4 | Expanding | 3d | 2025-01-27 | 2025-01-30 | 153 | 8d | 4d | 1403/11/11 | 1403/11/8 |
| 155 | 1.3.1.2.3.5 | Insert bundle to shell | 1d | 2025-02-03 | 2025-02-04 | 154, 141 | 4d | 0d | 1403/11/16 | 1403/11/15 |
| 156 | 1.3.1.2.3.6 | Assembly tube sheet to shell | 1d | 2025-02-04 | 2025-02-05 | 155 | 4d | 0d | 1403/11/17 | 1403/11/16 |
| 157 | 1.3.1.2.3.7 | Welding tube sheet to shell | 3d | 2025-02-05 | 2025-02-08 | 156 | 4d | 0d | 1403/11/20 | 1403/11/17 |
| 158 | 1.3.1.2.3.8 | Assembly saddle to shell | 1d | 2025-02-09 | 2025-02-09 | 157, 114 | 4d | 0d | 1403/11/21 | 1403/11/21 |
| 159 | 1.3.1.2.3.9 | Welding saddle to shell | 3d | 2025-02-10 | 2025-02-12 | 158 | 4d | 0d | 1403/11/24 | 1403/11/22 |
| 160 | 1.3.1.2.3.10 | Assembly external part to shell& channel | 1d | 2025-02-12 | 2025-02-13 | 159 | 4d | 0d | 1403/11/25 | 1403/11/24 |
| 161 | 1.3.1.2.3.11 | Welding external part to shell& channel | 2d | 2025-02-13 | 2025-02-16 | 160 | 4d | 0d | 1403/11/28 | 1403/11/25 |
| 162 | 1.3.1.2.3.12 | Final NDT | 1d | 2025-02-16 | 2025-02-17 | 161 | 4d | 0d | 1403/11/29 | 1403/11/28 |

| ID | WBS | Task | Duration | Start | Finish | Predecessors | Total slack | Free slack | پایان | شروع |
| --- | --- | --- | --- | --- | --- | --- | --- | --- | --- | --- |
| 163 | 1.3.1.3 | **Test** | 2d | 2025-02-17 | 2025-02-19 |  | 4d |  | 1403/12/1 | 1403/11/29 |
| 164 | 1.3.1.3.1 | Hydrostatic Test | 2d | 2025-02-17 | 2025-02-19 | 162, 70, 75, 149 | 4d | 0d | 1403/12/1 | 1403/11/29 |
| 165 | 1.3.1.4 | **Sandblast & paint** | 4d | 2025-02-19 | 2025-02-23 |  | 4d |  | 1403/12/5 | 1403/12/1 |
| 166 | 1.3.1.4.1 | Sandblast | 1d | 2025-02-19 | 2025-02-19 | 164 | 4d | 0d | 1403/12/1 | 1403/12/1 |
| 167 | 1.3.1.4.2 | Painting | 3d | 2025-02-19 | 2025-02-23 | 166, 83, 79, 6, 10 | 4d |  | 1403/12/5 | 1403/12/1 |
| 168 | 1.3.2 | **RU-0001A-E-02** | 79d | 2024-12-07 | 2025-02-27 |  | 0d |  | 1403/12/9 | 1403/9/17 |
| 169 | 1.3.2.1 | **Prefabrication** | 36d | 2024-12-07 | 2025-01-13 |  | 2d |  | 1403/10/24 | 1403/9/17 |
| 170 | 1.3.2.1.1 | **Shell** | 21d | 2024-12-07 | 2024-12-29 |  | 8d |  | 1403/10/9 | 1403/9/17 |
| 171 | 1.3.2.1.1.1 | Cutting | 2d | 2024-12-07 | 2024-12-09 | 25 | 8d | 0d | 1403/9/19 | 1403/9/17 |
| 172 | 1.3.2.1.1.2 | Beveling | 2d | 2024-12-09 | 2024-12-11 | 171 | 8d | 0d | 1403/9/21 | 1403/9/19 |
| 173 | 1.3.2.1.1.3 | Rolling | 2d | 2024-12-11 | 2024-12-14 | 172 | 8d | 0d | 1403/9/24 | 1403/9/21 |
| 174 | 1.3.2.1.1.4 | Assembly (LW) | 5d | 2024-12-14 | 2024-12-18 | 173 | 8d | 0d | 1403/9/28 | 1403/9/24 |
| 175 | 1.3.2.1.1.5 | Welding (LW) | 9d | 2024-12-18 | 2024-12-28 | 174 | 8d | 0d | 1403/10/8 | 1403/9/28 |
| 176 | 1.3.2.1.1.6 | Reroll | 1d | 2024-12-28 | 2024-12-29 | 175 | 8d | 0d | 1403/10/9 | 1403/10/8 |
| 177 | 1.3.2.1.2 | **Channel** | 15d | 2024-12-07 | 2024-12-23 |  | 2d |  | 1403/10/3 | 1403/9/17 |
| 178 | 1.3.2.1.2.1 | Cutting | 2d | 2024-12-07 | 2024-12-09 | 25 | 2d | 0d | 1403/9/19 | 1403/9/17 |
| 179 | 1.3.2.1.2.2 | Beveling | 2d | 2024-12-09 | 2024-12-11 | 178 | 2d | 0d | 1403/9/21 | 1403/9/19 |
| 180 | 1.3.2.1.2.3 | Rolling | 2d | 2024-12-11 | 2024-12-14 | 179 | 2d | 0d | 1403/9/24 | 1403/9/21 |
| 181 | 1.3.2.1.2.4 | Assembly (LW) | 3d | 2024-12-14 | 2024-12-16 | 180 | 2d | 0d | 1403/9/26 | 1403/9/24 |
| 182 | 1.3.2.1.2.5 | Welding (LW) | 5d | 2024-12-17 | 2024-12-22 | 181 | 2d | 0d | 1403/10/2 | 1403/9/27 |
| 183 | 1.3.2.1.2.6 | Reroll | 1d | 2024-12-22 | 2024-12-23 | 182 | 2d | 0d | 1403/10/3 | 1403/10/2 |
| 184 | 1.3.2.1.3 | **Cone** | 15d | 2024-12-07 | 2024-12-23 |  | 43d |  | 1403/10/3 | 1403/9/17 |
| 185 | 1.3.2.1.3.1 | Cutting | 2d | 2024-12-07 | 2024-12-09 | 25 | 43d | 0d | 1403/9/19 | 1403/9/17 |
| 186 | 1.3.2.1.3.2 | Beveling | 2d | 2024-12-09 | 2024-12-11 | 185 | 43d | 0d | 1403/9/21 | 1403/9/19 |
| 187 | 1.3.2.1.3.3 | Rolling | 2d | 2024-12-11 | 2024-12-14 | 186 | 43d | 0d | 1403/9/24 | 1403/9/21 |
| 188 | 1.3.2.1.3.4 | Assembly (LW) | 3d | 2024-12-14 | 2024-12-16 | 187 | 43d | 0d | 1403/9/26 | 1403/9/24 |
| 189 | 1.3.2.1.3.5 | Welding (LW) | 5d | 2024-12-17 | 2024-12-22 | 188 | 43d | 0d | 1403/10/2 | 1403/9/27 |
| 190 | 1.3.2.1.3.6 | Reroll | 1d | 2024-12-22 | 2024-12-23 | 189 | 43d | 35d | 1403/10/3 | 1403/10/2 |

| ID | WBS | Task | Duration | Start | Finish | Predecessors | Total slack | Free slack | پایان | شروع |
| --- | --- | --- | --- | --- | --- | --- | --- | --- | --- | --- |
| 191 | 1.3.2.1.4 | **Saddle fabrication** | 15d | 2024-12-07 | 2024-12-23 |  | 50d |  | 1403/10/3 | 1403/9/17 |
| 192 | 1.3.2.1.4.1 | Cutting | 2d | 2024-12-07 | 2024-12-09 | 25 | 50d | 0d | 1403/9/19 | 1403/9/17 |
| 193 | 1.3.2.1.4.2 | Beveling | 2d | 2024-12-09 | 2024-12-11 | 192 | 50d | 0d | 1403/9/21 | 1403/9/19 |
| 194 | 1.3.2.1.4.3 | Rolling | 2d | 2024-12-11 | 2024-12-14 | 193 | 50d | 0d | 1403/9/24 | 1403/9/21 |
| 195 | 1.3.2.1.4.4 | Assembly (LW) | 3d | 2024-12-14 | 2024-12-16 | 194 | 50d | 0d | 1403/9/26 | 1403/9/24 |
| 196 | 1.3.2.1.4.5 | Welding (LW) | 5d | 2024-12-17 | 2024-12-22 | 195 | 50d | 0d | 1403/10/2 | 1403/9/27 |
| 197 | 1.3.2.1.4.6 | Reroll | 1d | 2024-12-22 | 2024-12-23 | 196 | 50d |  | 1403/10/3 | 1403/10/2 |
| 198 | 1.3.2.1.5 | **Nozzle fabrication (part 1)** | 12d | 2024-12-18 | 2024-12-30 |  | 23d |  | 1403/10/10 | 1403/9/28 |
| 199 | 1.3.2.1.5.1 | Pipe cutting | 2d | 2024-12-18 | 2024-12-19 | 55FS+10d | 23d | 0d | 1403/9/29 | 1403/9/28 |
| 200 | 1.3.2.1.5.2 | Pipe beveling | 2d | 2024-12-19 | 2024-12-22 | 199 | 23d | 0d | 1403/10/2 | 1403/9/29 |
| 201 | 1.3.2.1.5.3 | Assembly pipe to flange | 3d | 2024-12-22 | 2024-12-25 | 200 | 23d | 0d | 1403/10/5 | 1403/10/2 |
| 202 | 1.3.2.1.5.4 | Welding pipe to flange | 5d | 2024-12-25 | 2024-12-30 | 201 | 23d | 15d | 1403/10/10 | 1403/10/5 |
| 203 | 1.3.2.1.6 | **Nozzle fabrication (part 2)** | 26d | 2024-12-18 | 2025-01-13 |  | 9d |  | 1403/10/24 | 1403/9/28 |
| 204 | 1.3.2.1.6.1 | Pipe cutting | 3d | 2024-12-18 | 2024-12-21 | 55FS+10d | 9d | 0d | 1403/10/1 | 1403/9/28 |
| 205 | 1.3.2.1.6.2 | Pipe beveling | 3d | 2024-12-21 | 2024-12-24 | 204 | 9d | 0d | 1403/10/4 | 1403/10/1 |
| 206 | 1.3.2.1.6.3 | Assembly pipe to flange | 5d | 2024-12-24 | 2024-12-29 | 205 | 9d | 0d | 1403/10/9 | 1403/10/4 |
| 207 | 1.3.2.1.6.4 | Welding pipe to flange | 7d | 2024-12-29 | 2025-01-05 | 206 | 9d | 0d | 1403/10/16 | 1403/10/9 |
| 208 | 1.3.2.1.6.5 | Assembly elbow to pipe | 3d | 2025-01-05 | 2025-01-08 | 207 | 9d | 0d | 1403/10/19 | 1403/10/16 |
| 209 | 1.3.2.1.6.6 | Welding elbow to pipe | 5d | 2025-01-08 | 2025-01-13 | 208 | 9d | 1d | 1403/10/24 | 1403/10/19 |
| 210 | 1.3.2.2 | **Final assembly** | 45d | 2025-01-05 | 2025-02-20 |  | 0d |  | 1403/12/2 | 1403/10/16 |
| 211 | 1.3.2.2.1 | **Shell** | 34d | 2025-01-05 | 2025-02-09 |  | 8d |  | 1403/11/21 | 1403/10/16 |
| 212 | 1.3.2.2.1.1 | Assembly shell segments (CW) | 3d | 2025-01-05 | 2025-01-08 | 176FS+7d | 8d | 0d | 1403/10/19 | 1403/10/16 |
| 213 | 1.3.2.2.1.2 | Welding shell segments (CW) | 5d | 2025-01-08 | 2025-01-13 | 212 | 8d | 0d | 1403/10/24 | 1403/10/19 |
| 214 | 1.3.2.2.1.3 | Opening for nozzle assembly | 1d | 2025-01-14 | 2025-01-14 | 213 | 8d | 0d | 1403/10/25 | 1403/10/25 |
| 215 | 1.3.2.2.1.4 | Nozzle assembly to shell | 3d | 2025-01-15 | 2025-01-18 | 214, 202, 209 | 8d | 0d | 1403/10/29 | 1403/10/26 |
| 216 | 1.3.2.2.1.5 | Nozzle welding to shell | 5d | 2025-01-18 | 2025-01-22 | 215 | 8d | 0d | 1403/11/3 | 1403/10/29 |
| 217 | 1.3.2.2.1.6 | Assembly head to shell | 2d | 2025-01-22 | 2025-01-25 | 216 | 8d | 0d | 1403/11/6 | 1403/11/3 |
| 218 | 1.3.2.2.1.7 | Welding head to shell | 3d | 2025-01-25 | 2025-01-28 | 217 | 8d | 0d | 1403/11/9 | 1403/11/6 |
| 219 | 1.3.2.2.1.8 | Assembly cone to shell | 1d | 2025-01-28 | 2025-01-29 | 218, 190 | 8d | 0d | 1403/11/10 | 1403/11/9 |
| 220 | 1.3.2.2.1.9 | Welding cone to shell | 3d | 2025-01-29 | 2025-02-01 | 219 | 8d | 0d | 1403/11/13 | 1403/11/10 |
| 221 | 1.3.2.2.1.10 | Assembly segment shell to cone | 1d | 2025-02-01 | 2025-02-02 | 220 | 8d | 0d | 1403/11/14 | 1403/11/13 |
| 222 | 1.3.2.2.1.11 | Welding segment shell to cone | 3d | 2025-02-02 | 2025-02-05 | 221 | 8d | 0d | 1403/11/17 | 1403/11/14 |
| 223 | 1.3.2.2.1.12 | Assembly body flange to shell | 1d | 2025-02-05 | 2025-02-06 | 222 | 8d | 0d | 1403/11/18 | 1403/11/17 |
| 224 | 1.3.2.2.1.13 | Welding body flange to shell | 3d | 2025-02-06 | 2025-02-09 | 223 | 8d | 6d | 1403/11/21 | 1403/11/18 |

| ID | WBS | Task | Duration | Start | Finish | Predecessors | Total slack | Free slack | پایان | شروع |
| --- | --- | --- | --- | --- | --- | --- | --- | --- | --- | --- |
| 225 | 1.3.2.2.2 | **Channel** | 16d | 2025-02-02 | 2025-02-19 |  | 2d |  | 1403/12/1 | 1403/11/14 |
| 226 | 1.3.2.2.2.1 | Assembly head to channel | 2d | 2025-02-02 | 2025-02-04 | 183FS+40d, 30 | 2d | 0d | 1403/11/16 | 1403/11/14 |
| 227 | 1.3.2.2.2.2 | Welding head to channel | 3d | 2025-02-04 | 2025-02-08 | 226 | 2d | 0d | 1403/11/20 | 1403/11/16 |
| 228 | 1.3.2.2.2.3 | Assembly body flange to channel | 2d | 2025-02-08 | 2025-02-09 | 227 | 2d | 0d | 1403/11/21 | 1403/11/20 |
| 229 | 1.3.2.2.2.4 | Welding body flange to channel | 3d | 2025-02-10 | 2025-02-12 | 228 | 2d | 0d | 1403/11/24 | 1403/11/22 |
| 230 | 1.3.2.2.2.5 | Opening for nozzle assembly | 1d | 2025-02-12 | 2025-02-13 | 229 | 2d | 0d | 1403/11/25 | 1403/11/24 |
| 231 | 1.3.2.2.2.6 | Assembly nozzle to channel | 2d | 2025-02-13 | 2025-02-16 | 230, 202, 209 | 2d | 0d | 1403/11/28 | 1403/11/25 |
| 232 | 1.3.2.2.2.7 | Welding nozzle to channel | 3d | 2025-02-16 | 2025-02-19 | 231, 224 | 2d |  | 1403/12/1 | 1403/11/28 |
| 233 | 1.3.2.2.3 | **Bundle structure** | 38d | 2025-01-13 | 2025-02-20 |  | 0d |  | 1403/12/2 | 1403/10/24 |
| 234 | 1.3.2.2.3.1 | Assembly bundle structure | 5d | 2025-01-13 | 2025-01-18 | 40, 45, 65FS+15d | 0d |  | 1403/10/29 | 1403/10/24 |
| 235 | 1.3.2.2.3.2 | Insert tube to bundle structure | 2d | 2025-01-18 | 2025-01-20 | 234, 35 | 0d |  | 1403/11/1 | 1403/10/29 |
| 236 | 1.3.2.2.3.3 | Tube to tube sheet welding | 15d | 2025-01-20 | 2025-02-04 | 235 | 0d |  | 1403/11/16 | 1403/11/1 |
| 237 | 1.3.2.2.3.4 | Expanding | 3d | 2025-02-04 | 2025-02-08 | 236 | 0d |  | 1403/11/20 | 1403/11/16 |
| 238 | 1.3.2.2.3.5 | Insert bundle to shell | 1d | 2025-02-08 | 2025-02-08 | 237 | 0d |  | 1403/11/20 | 1403/11/20 |
| 239 | 1.3.2.2.3.6 | Assembly tube sheet to shell | 1d | 2025-02-09 | 2025-02-09 | 238 | 0d |  | 1403/11/21 | 1403/11/21 |
| 240 | 1.3.2.2.3.7 | Welding tube sheet to shell | 3d | 2025-02-10 | 2025-02-12 | 239 | 0d |  | 1403/11/24 | 1403/11/22 |
| 241 | 1.3.2.2.3.8 | Assembly saddle to shell | 1d | 2025-02-12 | 2025-02-13 | 197, 240 | 0d |  | 1403/11/25 | 1403/11/24 |
| 242 | 1.3.2.2.3.9 | Welding saddle to shell | 3d | 2025-02-13 | 2025-02-17 | 241 | 0d |  | 1403/11/29 | 1403/11/25 |
| 243 | 1.3.2.2.3.10 | Assembly external part to shell& channel | 1d | 2025-02-17 | 2025-02-18 | 242 | 0d |  | 1403/11/30 | 1403/11/29 |
| 244 | 1.3.2.2.3.11 | Welding external part to shell& channel | 2d | 2025-02-18 | 2025-02-19 | 243 | 0d |  | 1403/12/1 | 1403/11/30 |
| 245 | 1.3.2.2.3.12 | Final NDT | 1d | 2025-02-19 | 2025-02-20 | 244 | 0d |  | 1403/12/2 | 1403/12/1 |
| 246 | 1.3.2.3 | **Test** | 2d | 2025-02-20 | 2025-02-23 |  | 0d |  | 1403/12/5 | 1403/12/2 |
| 247 | 1.3.2.3.1 | Hydrostatic Test | 2d | 2025-02-20 | 2025-02-23 | 245, 232, 70, 75 | 0d |  | 1403/12/5 | 1403/12/2 |
| 248 | 1.3.2.4 | **Sandblast & paint** | 4d | 2025-02-23 | 2025-02-27 |  | 0d |  | 1403/12/9 | 1403/12/5 |
| 249 | 1.3.2.4.1 | Sandblast | 1d | 2025-02-23 | 2025-02-24 | 247 | 0d |  | 1403/12/6 | 1403/12/5 |
| 250 | 1.3.2.4.2 | Painting | 3d | 2025-02-24 | 2025-02-27 | 249, 83, 79, 6, 10 | 0d |  | 1403/12/9 | 1403/12/6 |
